# RHEA

How a schedule from MS Project changed from version to version. A marks actual dates.

## Version 1 (saved 2012-07-17, file 120717 RHEA project plan MS-Project 2003.mpp)

| ID | WBS | Task | Duration | Start | Finish | Predecessors | Complete | Total float | Constraint |
| --- | --- | --- | --- | --- | --- | --- | --- | --- | --- |
| 1 | 1 | **Project management** | 93d | 2012-05-22 A | 2012-09-27 |  | 50% | 57.43d |  |
| 2 |  | Day to day project management | 4mo | 2012-05-22 A | 2012-09-10 |  | 50% | 70.43d |  |
| 3 |  | Day to day technical management | 4mo | 2012-05-22 A | 2012-09-10 |  | 50% | 70.43d |  |
| 4 |  | submit Apelon subcontract approval to CARDNO | 1h | 2012-05-23 A | 2012-05-23 A |  | 100% |  | start no earlier than 2012-05-23 |
| 5 |  | draft Apelon subcontract | 4d | 2012-05-23 A | 2012-05-29 A | 4 | 100% |  |  |
| 6 |  | Sign Apelon subcontract | 5d | 2012-05-29 A | 2012-06-05 A | 5 | 100% |  |  |
| 7 |  | Submit Sysnet subcontract approval to CARDNO | 1h | 2012-05-29 A | 2012-05-29 A |  | 100% |  | start no earlier than 2012-05-29 |
| 8 |  | Draft Sysnet/Regenstrief subcontract | 2d | 2012-05-29 A | 2012-05-31 A | 7 | 100% |  | start no earlier than 2012-05-18 |
| 9 |  | Sign Sysnet/Regenstrief subcontract | 5d | 2012-05-31 A | 2012-06-07 A | 8 | 100% |  |  |
| 10 |  | Secure NDC server space | 8w | 2012-05-22 A | 2012-07-16 |  | 40% | 110.43d |  |
| 11 |  | Develop M&E plan | 3w | 2012-05-22 A | 2012-06-11 |  | 40% | 135.43d |  |
| 12 |  | RHEA Sept Meeting | 4d | 2012-09-24 A | 2012-09-27 |  | 10% | 0d | must start on 2012-09-24 |
| 13 | 2 | **Terminology Service** | 104d? | 2012-05-22 A | 2012-10-12 |  | 16% | 46.43d |  |
| 14 | 2.1 | **Technical Development** | 8.25d | 2012-05-22 A | 2012-06-01 |  | 39% | 14.75d |  |
| 15 |  | Web-UI Review | 1w | 2012-05-22 A | 2012-05-28 A |  | 100% |  |  |
| 16 |  | Developer Integration Testing | 1.65w | 2012-05-22 A | 2012-06-01 |  | 30% | 14.75d |  |
| 17 |  | Load Code Sets (LOINC-RW) | 1w | 2012-05-22 | 2012-05-28 |  |  | 18d |  |
| 18 |  | Develop Data Recovery and Backup Solution | 1w | 2012-05-22 A | 2012-05-28 |  | 30% | 18d |  |
| 19 |  | Identify server requirements | 1d | 2012-06-04 A | 2012-06-04 A |  | 100% |  | must start on 2012-06-04 |
| 20 |  | MoH system approval | 1d | 2012-06-22 | 2012-06-22 | 14 |  | 0d | must start on 2012-06-22 |
| 21 | 2.4 | **Deploy on TS Server** | 35.75d? | 2012-06-01 A | 2012-07-20 |  | 17% | 0d |  |
| 22 |  | Deploy in Jembi EC2 | 1d? | 2012-06-01 A | 2012-06-04 A | 14 | 100% |  |  |
| 23 |  | Deploy in NDC | 1w | 2012-07-16 | 2012-07-20 | 20 |  | 0d | must start on 2012-07-16 |
| 24 |  | Documentation Sprint | 2w | 2012-06-01 A | 2012-06-15 | 14 | 50% | 132.18d |  |
| 25 |  | Decide training and support plans | 2w | 2012-06-07 A | 2012-06-20 |  | 90% | 0d | must start on 2012-06-07 |
| 26 |  | Training and support material developed | 3w | 2012-06-21 | 2012-07-11 | 25 |  | 113.43d | start no earlier than 2012-06-11 |
| 27 |  | Training | 4d | 2012-07-23 | 2012-07-26 | 21 |  | 31d |  |
| 28 |  | Apelon technical support | 4mo | 2012-06-25 | 2012-10-12 | 20 |  | 46.43d |  |
| 29 |  | System evaluation | 1.5d | 2012-09-10 | 2012-09-11 | 27 |  | 0d | must start on 2012-09-10 |
| 30 | 3 | **Facility Registry** | 119d | 2012-05-22 A | 2012-11-02 |  | 26% | 31.43d |  |
| 31 | 3.1 | **Technical development** | 15d | 2012-06-05 A | 2012-06-25 |  | 90% | 0d |  |
| 32 |  | Testing and bug fixes | 3w | 2012-06-05 A | 2012-06-25 |  | 90% | 0d | must start on 2012-06-05 |
| 33 |  | MoH system approval | 2d | 2012-06-26 A | 2012-06-27 | 31 | 60% | 123.43d |  |
| 34 |  | Decide server requirements | 2d | 2012-05-22 A | 2012-05-23 A |  | 100% |  |  |
| 35 |  | Support structure designed | 1w | 2012-06-08 A | 2012-06-14 |  | 60% | 0d | must start on 2012-06-08 |
| 36 |  | Training and support plans decided | 0.6w | 2012-06-15 A | 2012-06-19 |  | 60% | 0d | must start on 2012-06-15 |
| 37 |  | Training and support materials developed | 3w | 2012-06-20 A | 2012-07-10 | 36 | 40% | 114.43d |  |
| 38 |  | Pre-training prep | 4w | 2012-06-25 A | 2012-07-20 |  | 50% | 0d | must start on 2012-06-25 |
| 39 |  | Training | 1w | 2012-08-13 | 2012-08-17 | 38 |  | 0d | must start on 2012-08-13 |
| 40 |  | deployment | 1w | 2012-07-23 | 2012-07-27 |  |  | 0d | must start on 2012-07-23 |
| 41 |  | System support | 3.5mo | 2012-07-30 | 2012-11-02 | 40 |  | 31.43d |  |
| 42 |  | Evaluation | 1w | 2012-09-17 | 2012-09-21 | 40 |  | 0d | must start on 2012-09-17 |
| 43 | 4 | **Client Registry** | 90d? | 2012-05-22 A | 2012-09-24 |  | 10% | 60.43d |  |
| 44 |  | Odysseas trip to Indy | 1d? | 2012-05-22 | 2012-05-22 |  |  | 38d |  |
| 45 | 4.2 | **Technical evaluation** | 53d | 2012-05-22 A | 2012-08-02 |  | 2% | 97.43d |  |
| 46 |  | OpenEMPI source code available | 1d | 2012-05-22 A | 2012-05-22 A |  | 100% |  | start no earlier than 2012-05-21 |
| 47 |  | Requirements specifications | 1.8w | 2012-07-16 | 2012-07-26 |  |  | 0d | must start on 2012-07-16 |
| 48 |  | Document Security Model for pilot | 2d | 2012-07-16 | 2012-07-17 | 44 |  | 0d | must start on 2012-07-16 |
| 49 |  | Document Actors/Actions | 2d | 2012-07-16 | 2012-07-17 | 44 |  | 0d | start no earlier than 2012-07-16 |
| 50 |  | Create sequence diagram | 1d | 2012-07-18 | 2012-07-18 | 49 |  | 0d | must start on 2012-07-18 |
| 51 |  | messaging filters | 2d | 2012-07-16 | 2012-07-17 | 44 |  | 0d | must start on 2012-07-16 |
| 52 |  | Document performance goals of transactions | 2d | 2012-07-16 | 2012-07-17 | 44 |  | 0d | must start on 2012-07-16 |
| 53 |  | Reporting requirements definition | 4d | 2012-07-16 | 2012-07-19 | 44 |  | 0d | must start on 2012-07-16 |
| 54 |  | Draft review | 2d | 2012-07-19 | 2012-07-20 |  |  | 0d | must start on 2012-07-19 |
| 55 |  | Update from review | 2d | 2012-07-23 | 2012-07-24 |  |  | 0d | must start on 2012-07-23 |
| 56 |  | Confirm compliance | 2d | 2012-07-25 | 2012-07-26 |  |  | 102.43d | start no earlier than 2012-07-25 |
| 57 | 4.2.12 | **Review of data** | 24d | 2012-07-02 | 2012-08-02 |  |  | 0d | start no earlier than 2012-05-22 |
| 58 |  | Access to production data - Ubudehe data | 1d | 2012-07-02 | 2012-07-02 |  |  | 0d | must start on 2012-07-02 |
| 59 |  | Remote access to production data - Ubedehe data | 1.8w | 2012-07-03 | 2012-07-13 | 58 |  | 0d | must start on 2012-07-03 |
| 60 |  | OpenMRS database | 1d | 2012-07-03 | 2012-07-03 | 58 |  | 0d | must start on 2012-07-03 |
| 61 |  | Data analysis | 1.8w | 2012-07-23 | 2012-08-02 |  |  | 0d | must start on 2012-07-23 |
| 62 |  | Identifing fields and candidated for matching | 1.2w | 2012-07-23 | 2012-07-30 | 54 |  | 0d | must start on 2012-07-23 |
| 63 |  | Map data between OpenMRS and Ubudehe | 2d | 2012-07-31 | 2012-08-01 | 62 |  | 0d | must start on 2012-07-31 |
| 64 |  | Recommend what fields to use | 1d | 2012-07-31 | 2012-07-31 | 62 |  | 0d | must start on 2012-07-31 |
| 65 |  | Finalize data elements for clients | 2d | 2012-08-01 | 2012-08-02 | 64 |  | 0d | must start on 2012-08-01 |
| 66 | 4.3 | **Technical Development** | 73d? | 2012-05-22 A | 2012-08-30 |  | 21% | 0d |  |
| 67 |  | Install software in development environment (JHSR Office) | 1mo | 2012-05-22 A | 2012-06-18 |  | 50% | 0d | must start on 2012-05-22 |
| 68 |  | Define identifier domains | 1d? | 2012-05-22 A | 2012-05-22 A | 44 | 100% |  | must start on 2012-07-16 |
| 69 |  | EC2 Dev Server Instance | 1d? | 2012-05-22 A | 2012-05-22 A |  | 100% |  | must start on 2012-05-22 |
| 70 |  | EC2 configuration | 1d? | 2012-07-17 A | 2012-07-17 A | 69 | 100% |  | must start on 2012-07-17 |

| ID | WBS | Task | Duration | Start | Finish | Predecessors | Complete | Total float | Constraint |
| --- | --- | --- | --- | --- | --- | --- | --- | --- | --- |
| 71 |  | Modify OpenEMPI data model | 1w? | 2012-08-03 | 2012-08-09 | 61 |  | 0d | must start on 2012-08-03 |
| 72 |  | Modify OpenEMPI data loader | 1w? | 2012-08-10 | 2012-08-16 | 71 |  | 0d | must start on 2012-08-10 |
| 73 |  | Software Release 1 - Data model & Loader changes | 1d? | 2012-08-17 | 2012-08-17 | 72 |  | 0d | must start on 2012-08-17 |
| 74 |  | Software Release 2 - Matching Algorithm Enhancements | 2w? | 2012-08-17 | 2012-08-30 | 81 |  | 0d | must start on 2012-08-17 |
| 75 |  | Software Release 3 Performance tuning enhancements | 1w? | 2012-08-24 | 2012-08-30 | 87 |  | 0d | must start on 2012-08-24 |
| 76 |  | Staging server access | 1d? | 2012-08-06 | 2012-08-06 |  |  | 0d | must start on 2012-08-06 |
| 77 |  | Staging server instillation | 2d? | 2012-08-07 | 2012-08-08 | 76 |  | 0d | must start on 2012-08-07 |
| 78 |  | Staging server configuration | 2d? | 2012-08-09 | 2012-08-10 | 77 |  | 0d | must start on 2012-08-09 |
| 79 |  | Data load | 2d? | 2012-08-13 | 2012-08-14 | 78 |  | 0d | must start on 2012-08-13 |
| 80 |  | Report development | 1w? | 2012-07-20 | 2012-07-26 | 53 |  | 0d | must start on 2012-07-20 |
| 81 | 4.4 | **Defining the algorithm** | 10d? | 2012-08-03 | 2012-08-16 |  |  | 0d | must start on 2012-08-03 |
| 82 |  | Parameterize algorithm | 2d? | 2012-08-03 | 2012-08-06 | 61 |  | 0d | must start on 2012-08-03 |
| 83 |  | Validate algorithm | 1d? | 2012-08-07 | 2012-08-07 | 82 |  | 1d |  |
| 84 |  | Review results | 2d? | 2012-08-09 | 2012-08-10 | 83 |  | 0d | must start on 2012-08-09 |
| 85 |  | Accept algorithm | 2d? | 2012-08-13 | 2012-08-14 | 84 |  | 0d | must start on 2012-08-13 |
| 86 |  | Development modifications | 2d? | 2012-08-15 | 2012-08-16 | 85 |  | 0d | must start on 2012-08-15 |
| 87 | 4.5 | **Performance Testing of OpenEMPI** | 20d? | 2012-07-27 | 2012-08-23 |  |  | 0d | must start on 2012-07-27 |
| 88 |  | Define testing transactions | 4d? | 2012-07-27 | 2012-08-01 |  |  | 0d | must start on 2012-07-27 |
| 89 |  | Run test | 2d? | 2012-08-20 | 2012-08-21 | 88 |  | 0d | must start on 2012-08-20 |
| 90 |  | Review results | 2d? | 2012-08-22 | 2012-08-23 | 89 |  | 0d | must start on 2012-08-22 |
| 91 | 4.6 | **Deployment activities** | 84d? | 2012-05-22 A | 2012-09-14 |  | 18% | 0d |  |
| 92 |  | Production server access | 1w? | 2012-07-13 A | 2012-07-19 A |  | 100% |  | must start on 2012-08-06 |
| 93 |  | Production installation | 1w? | 2012-08-13 | 2012-08-17 | 92 |  | 4.5d | start no earlier than 2012-08-13 |
| 94 |  | Production configuration | 5d | 2012-05-22 A | 2012-08-24 | 93 | 10% | 0d | must start on 2012-08-20 |
| 95 |  | Load data from Ubedehe | 3d | 2012-08-27 | 2012-08-29 | 94 |  | 0d | must start on 2012-08-27 |
| 96 |  | Load OpenMRS data | 3d | 2012-08-30 | 2012-09-03 | 95 |  | 0d | must start on 2012-08-30 |
| 97 |  | Functional testing | 3d | 2012-09-04 | 2012-09-06 | 96 |  | 0d | must start on 2012-09-04 |
| 98 |  | Performance testing | 3d | 2012-09-07 | 2012-09-11 | 97 |  | 0d | must start on 2012-09-07 |
| 99 |  | Intergration testing | 3d | 2012-09-12 | 2012-09-14 | 98 |  | 0d | must start on 2012-09-12 |
| 100 |  | MoH system approval | 1d? | 2012-09-17 | 2012-09-17 | 99 |  | 0d | must start on 2012-09-17 |
| 101 | 4.8 | **Training and Support** | 54d? | 2012-06-19 A | 2012-08-31 |  | 5% | 0d |  |
| 102 |  | Define support requirements | 2.5d? | 2012-06-19 A | 2012-06-21 | 67 | 80% | 0d | must start on 2012-05-22 |
| 103 |  | Develop training and support material | 1.75mo | 2012-07-16 | 2012-08-31 | 69, 102 |  | 0d | must start on 2012-07-16 |
| 104 |  | Virtual training | 1d | 2012-08-30 | 2012-08-30 |  |  | 0d | must start on 2012-08-30 |
| 105 |  | On-site training | 1w | 2012-08-27 | 2012-08-31 |  |  | 0d | must start on 2012-08-27 |
| 106 |  | Evaluation | 1w | 2012-09-18 | 2012-09-24 | 91 |  | 0d | must start on 2012-09-18 |
| 107 | 5 | **Provider Registry** | 99d? | 2012-05-22 A | 2012-10-05 |  | 43% | 51.43d |  |
| 108 | 5.1 | **Technical development** | 44d? | 2012-05-22 A | 2012-07-20 |  | 60% | 0d |  |
| 109 | 5.1.1 | **Software Platform Determined** | 9d | 2012-05-22 A | 2012-06-01 A |  | 100% |  |  |
| 110 |  | Review and Evaluation | 8d | 2012-05-22 A | 2012-05-31 A |  | 100% |  |  |
| 111 |  | Recommendation made with justification | 1d | 2012-06-01 A | 2012-06-01 A | 110 | 100% |  |  |
| 112 | 5.1.2 | **Public Registry (PR) specifications and customizations document** | 4.67d? | 2012-06-04 A | 2012-06-08 A | 109 | 100% |  |  |
| 113 |  | Draft | 4d | 2012-06-04 A | 2012-06-07 A |  | 100% |  |  |
| 114 |  | Review | 5.33h | 2012-06-08 A | 2012-06-08 A | 113 | 100% |  |  |
| 115 |  | Finalise | 1d? | 2012-06-04 A | 2012-06-04 A |  | 100% |  |  |
| 116 | 5.1.3 | **Collect Provider Registry data sources from iHRIS and Liz/RapidSMS (possibly OpenMRS)** | 25d | 2012-06-04 A | 2012-07-06 A |  | 100% |  |  |
| 117 |  | iHRIS | 5w | 2012-06-04 A | 2012-07-06 A |  | 100% |  | must start on 2012-06-04 |
| 118 |  | CHW RapidSMS | 5w | 2012-06-04 A | 2012-07-06 A |  | 100% |  | must start on 2012-06-04 |
| 119 |  | OpenMRS | 5w | 2012-06-04 A | 2012-07-06 A |  | 100% |  | must start on 2012-06-04 |
| 120 |  | Implementing customizations to PR UI | 6w | 2012-06-11 | 2012-07-20 | 112 |  | 0d | must start on 2012-06-11 |
| 121 |  | Implementing customisations to PR Web Services | 6w | 2012-06-11 | 2012-07-20 |  |  | 0d | must start on 2012-06-11 |
| 122 |  | MoH system approval | 1w | 2012-07-30 | 2012-08-03 | 120, 121 |  | 0d | must start on 2012-07-30 |
| 123 |  | Decide server requirements | 1w | 2012-06-04 A | 2012-06-08 | 109 | 40% | 136.43d |  |
| 124 |  | Document support requirements | 3w | 2012-05-22 A | 2012-06-11 |  | 80% | 6d |  |
| 125 |  | Develop training and support plans | 1w | 2012-06-13 A | 2012-06-19 | 124, 109 | 40% | 0d | must start on 2012-06-13 |
| 126 |  | Develop trainng and support material | 4w | 2012-07-09 | 2012-08-03 | 125 |  | 0d | must start on 2012-07-09 |
| 127 | 5.7 | **Training** | 48d | 2012-06-13 A | 2012-08-17 |  | 50% | 0d |  |
| 128 |  | Schedule training | 1w | 2012-06-13 A | 2012-06-19 A |  | 100% |  | must start on 2012-06-13 |
| 129 |  | Training | 1w | 2012-08-13 | 2012-08-17 | 126, 128 |  | 0d | must start on 2012-08-13 |
| 130 |  | Evaluation | 1w | 2012-09-17 | 2012-09-21 | 127 |  | 0d | must start on 2012-09-17 |
| 131 |  | System support | 8w | 2012-08-13 | 2012-10-05 |  |  | 0d | must start on 2012-08-13 |
| 132 | 6 | **OpenMRS** | 108d? | 2012-05-22 A | 2012-10-18 |  | 40% | 42.43d |  |
| 133 | 6.1 | **Technical development** | 82.5d | 2012-05-22 A | 2012-09-13 |  | 59% | 67.43d |  |
| 134 |  | Update OMRS Concept Dictionaries at MoH Sites with Maternal Data Mappings | 8w | 2012-05-22 A | 2012-07-16 |  | 90% | 99.93d |  |
| 135 |  | Update HTML Form Implementations and Link them with Final Maternal Data Mappings | 7w | 2012-05-29 A | 2012-07-20 | 134 | 90% | 96.43d |  |
| 136 |  | Rwandan Primary Care and RHEA API Integration Design | 6w | 2012-06-05 A | 2012-07-30 | 135 | 80% | 90.43d |  |
| 137 |  | Development - Rwandan Primary Care + RHEA API Integration | 5w | 2012-06-19 A | 2012-08-06 | 136 | 80% | 85.43d |  |
| 138 |  | Maternal Summary Development | 3w | 2012-06-25 A | 2012-07-13 |  |  | 105.93d |  |
| 139 |  | Integration Testing | 4w | 2012-07-03 A | 2012-08-30 | 137 | 10% | 67.43d |  |
| 140 |  | Update Design Documentation | 1w | 2012-07-16 | 2012-07-20 | 138 |  | 105.93d |  |

| ID | WBS | Task | Duration | Start | Finish | Predecessors | Complete | Total float | Constraint |
| --- | --- | --- | --- | --- | --- | --- | --- | --- | --- |
| 141 |  | Develop User Documentation | 4w | 2012-07-03 A | 2012-08-28 | 137, 138 | 20% | 79.43d |  |
| 142 |  | RHEA Team Testing and Iteration | 2w | 2012-08-30 | 2012-09-13 | 139 |  | 67.43d |  |
| 143 |  | MoH system approval | 4h? | 2012-09-13 | 2012-09-13 | 133 |  | 67.43d |  |
| 144 |  | Pre-rollout clinic site assessments | 2w | 2012-05-22 A | 2012-06-04 A |  | 100% |  |  |
| 145 |  | Develop training and support plan | 2w | 2012-06-05 A | 2012-06-18 | 144 | 80% | 130.43d |  |
| 146 |  | Site infrustructure and hardware rollout | 1mo | 2012-06-05 A | 2012-07-02 | 144 | 70% | 120.43d |  |
| 147 | 6.6 | **Deployment** | 37d? | 2012-07-18 A | 2012-09-06 |  | 5% | 0d |  |
| 148 |  | ANC clinic computers | 3.2w? | 2012-07-18 A | 2012-08-08 |  | 10% | 0d | must start on 2012-07-18 |
| 149 |  | RHEA PHC module | 3.6w? | 2012-08-14 | 2012-09-06 |  |  | 0d | must start on 2012-08-14 |
| 150 |  | Uploading of Ubhuthe database info on site | 3.6w? | 2012-08-14 | 2012-09-06 |  |  | 0d | must start on 2012-08-14 |
| 151 | 6.8 | **Training** | 52d? | 2012-06-26 A | 2012-09-05 |  | 6% | 0d |  |
| 152 |  | IT skills training | 1.6mo? | 2012-06-26 A | 2012-08-08 |  | 10% | 0d | must start on 2012-06-28 |
| 153 |  | Application training | 3.6w? | 2012-08-13 | 2012-09-05 | 152 |  | 0d | must start on 2012-08-13 |
| 154 |  | System support | 6w | 2012-09-07 | 2012-10-18 | 147 |  | 42.43d |  |
| 155 |  | Evaluation | 2w | 2012-09-10 | 2012-09-21 |  |  | 61.43d | start no earlier than 2012-09-10 |
| 156 | 7 | **RapidSMS** | 1d? | 2012-05-22 | 2012-05-22 |  |  | 149.43d |  |
| 157 |  | System testing | 1d? | 2012-05-22 | 2012-05-22 |  |  | 149.43d |  |
| 158 | 8 | **Shared Health Record** | 129d? | 2012-05-22 A | 2012-11-16 |  | 37% | 21.43d |  |
| 159 | 8.1 | **Technical development** | 70d | 2012-05-22 A | 2012-08-27 |  | 65% | 80.43d |  |
| 160 |  | API Development | 9w | 2012-05-22 A | 2012-07-23 |  | 80% | 102.93d |  |
| 161 |  | Developer Unit + Integtration Testing and Code Reviews | 10w | 2012-05-24 A | 2012-08-27 | 160 | 50% | 80.43d |  |
| 162 |  | Develop Load and Performance Testing Plan | 1w | 2012-07-16 A | 2012-07-20 A |  | 100% |  |  |
| 163 |  | Develop Backup and Redudancy Strategy | 1w | 2012-07-23 A | 2012-07-27 A | 162 | 100% |  |  |
| 164 |  | Load and Performance Testing | 2w | 2012-07-30 A | 2012-08-10 A | 163, 162 | 100% |  |  |
| 165 |  | RHEA Team System Testing + Iteration | 2w | 2012-08-13 | 2012-08-24 | 164 |  | 21.43d |  |
| 166 |  | MoH system approval | 2d | 2012-08-27 | 2012-08-28 | 165 |  | 79.43d |  |
| 167 |  | Deployment | 1w | 2012-08-27 | 2012-08-31 | 165 |  | 76.43d |  |
| 168 |  | Decide server requirements | 1d | 2012-05-22 | 2012-05-22 |  |  | 149.43d |  |
| 169 |  | Develop training and support plan | 5d | 2012-07-23 A | 2012-07-27 |  | 30% | 81.43d | start no earlier than 2012-06-05 |
| 170 |  | Develop training and support material | 20d | 2012-07-27 | 2012-08-24 | 169 |  | 81.43d |  |
| 171 |  | Training | 5d | 2012-08-27 | 2012-08-31 | 165 |  | 76.43d |  |
| 172 |  | System support | 3mo | 2012-08-27 | 2012-11-16 | 165 |  | 21.43d |  |
| 173 |  | Evaluation | 1d? | 2012-05-22 | 2012-05-22 |  |  | 149.43d |  |
| 174 | 9 | **Interoperability layer** | 150.43d | 2012-05-22 A | 2012-12-18 |  | 29% | 0d |  |
| 175 | 9.1 | **Technical development** | 51d | 2012-05-22 A | 2012-07-31 |  | 69% | 0d |  |
| 176 |  | Develop Transaction Overview Page | 1w | 2012-05-22 A | 2012-05-28 A |  | 100% |  |  |
| 177 |  | Develop Transaction View page | 1w | 2012-05-29 A | 2012-06-04 A | 176 | 100% |  |  |
| 178 |  | Develop Monitoring page | 1w | 2012-06-05 A | 2012-06-11 A | 177 | 100% |  |  |
| 179 |  | Develop Login functionality | 1w | 2012-06-12 A | 2012-06-18 A | 178 | 100% |  |  |
| 180 |  | Develop Transaction Edit page | 1w | 2012-06-19 A | 2012-06-25 | 179 | 70% | 26d |  |
| 181 |  | Develop Audit Log functionality | 1w | 2012-06-26 A | 2012-07-02 | 180 | 70% | 21d |  |
| 182 |  | System Testing and bug fixes | 1.05mo | 2012-07-03 A | 2012-07-31 | 178, 179, 181, 180, 177, 176 | 40% | 0d | must finish on 2012-07-31 |
| 183 |  | User Documentation Sprint | 2w | 2012-08-01 | 2012-08-14 | 175 |  | 3d |  |
| 184 |  | Technical Documentation Sprint | 2w | 2012-07-17 A | 2012-08-03 | 175 | 70% | 10d |  |
| 185 |  | Implement Orchestrations for developed components | 2w | 2012-07-17 A | 2012-08-02 | 182 | 80% | 6d |  |
| 186 |  | MoH system approval | 1d | 2012-08-01 | 2012-08-01 | 175 |  | 7d |  |
| 187 |  | Deploy system | 1.14w | 2012-08-13 | 2012-08-20 | 186, 185 |  | 0d | must start on 2012-08-13 |
| 188 |  | Identify server requirements | 1.43d | 2012-05-22 A | 2012-05-23 A |  | 100% |  |  |
| 189 |  | Develop training and support plans | 2w | 2012-06-18 A | 2012-06-29 |  | 40% | 0d | must start on 2012-06-18 |
| 190 |  | Training | 1.43w | 2012-08-20 | 2012-08-29 | 184, 183, 186 |  | 0d | must start on 2012-08-20 |
| 191 |  | System support | 4.29mo | 2012-08-20 | 2012-12-18 | 187 |  | 0d |  |
| 192 |  | Evaluation | 2.5d | 2012-09-17 | 2012-09-19 | 187 |  | 0d | must start on 2012-09-17 |

## Version 2 (saved 2012-07-30, file 120723 RHEA Project Plan_MS Project2003.mpp)

Last finish stays 2012-12-18. Complete tasks 33 → 40.

Added:

| ID | Task | Duration | Start | Finish | Predecessors | Constraint |
| --- | --- | --- | --- | --- | --- | --- |
| 156 | System testing and bug fixing | 1mo? | 2012-08-06 | 2012-08-31 |  | must start on 2012-08-06 |
| 189 | Develop training and support material | 2w | 2012-08-13 | 2012-08-24 | 188 | start no earlier than 2012-08-13 |

Removed: 149 RHEA PHC module; 157 System testing

Changed:

| ID | Task | Start | Finish | Duration | Complete | Total float | Predecessors | Other |
| --- | --- | --- | --- | --- | --- | --- | --- | --- |
| 1 | **Project management** |  |  |  | 50% → 54% |  |  |  |
| 2 | Day to day project management |  |  |  | 50% → 55% |  |  | resources Carl Fourie [15%]; Rhonwyn Cornell → Rhonwyn Cornell; Carl Fourie [15%] |
| 3 | Day to day technical management |  |  |  | 50% → 55% |  |  | resources Wayne Naidoo; Carl Fourie [15%] → Carl Fourie [15%]; Wayne Naidoo |
| 5 | draft Apelon subcontract |  |  |  |  |  |  | resources Carl Fourie; Rhonwyn Cornell [25%]; Jonnea Smith [50%] → Jonnea Smith [50%]; Carl Fourie; Rhonwyn Cornell [25%] |
| 11 | Develop M&E plan |  |  |  |  |  |  | resources Wayne Naidoo [6.7%]; Rhonwyn Cornell [33.3%]; Emmanuel Rugomboka [20%]; Carl Fourie [6.7%] → Rhonwyn Cornell [33.3%]; Wayne Naidoo [6.7%]; Emmanuel Rugomboka [20%]; Carl Fourie [6.7%] |
| 13 | **Terminology Service** |  |  |  | 16% → 22% |  |  |  |
| 23 | Deploy in NDC |  |  |  |  |  |  | resources Hannes Venter [50%]; Ishimwe Ngezahayo [50%] → Ishimwe Ngezahayo [50%]; Hannes Venter [50%] |
| 24 | Documentation Sprint |  |  |  | 50% → 60% |  |  |  |
| 25 | Decide training and support plans |  |  |  |  |  |  | resources Apelon Inc [4%]; Rhonwyn Cornell [2%] → Rhonwyn Cornell [2%]; Apelon Inc [4%] |
| 26 | Training and support material developed |  |  |  |  |  |  | resources Apelon Inc [15%]; Hannes Venter [5%] → Hannes Venter [5%]; Apelon Inc [15%] |
| 28 | Apelon technical support | 2012-06-25 A |  |  | 0% → 10% |  |  |  |
| 29 | System evaluation |  |  |  |  |  |  | resources Rhonwyn Cornell; Wayne Naidoo → Wayne Naidoo; Rhonwyn Cornell |
| 30 | **Facility Registry** |  |  |  | 26% → 31% |  |  |  |
| 36 | Training and support plans decided |  |  |  | 60% → 80% |  |  |  |
| 37 | Training and support materials developed |  |  |  | 40% → 60% |  |  |  |
| 38 | Pre-training prep |  |  |  | 50% → 70% |  |  |  |
| 43 | **Client Registry** |  |  |  | 10% → 17% |  |  |  |
| 45 | **Technical evaluation** |  |  |  | 2% → 20% |  |  |  |
| 57 | **Review of data** | 2012-07-02 A |  |  | 0% → 35% |  |  |  |
| 58 | Access to production data - Ubudehe data | 2012-07-02 A | 2012-07-02 A |  | 0% → 100% | 0d → none |  |  |
| 59 | Remote access to production data - Ubedehe data | 2012-07-03 A | 2012-07-13 A |  | 0% → 100% | 0d → none |  |  |
| 60 | OpenMRS database | 2012-07-03 A | 2012-07-03 A |  | 0% → 100% | 0d → none |  |  |
| 76 | Staging server access |  |  | 1d? → 1d |  |  |  |  |
| 77 | Staging server instillation |  |  | 2d? → 2d |  |  |  |  |
| 78 | Staging server configuration |  |  | 2d? → 2d |  |  |  |  |
| 79 | Data load |  |  | 2d? → 2d |  |  |  |  |
| 80 | Report development |  |  | 1w? → 1w |  |  |  |  |
| 91 | **Deployment activities** |  |  |  | 18% → 35% |  |  |  |
| 93 | Production installation | 2012-08-13 A | 2012-08-17 A |  | 0% → 100% | 4.5d → none |  |  |
| 103 | Develop training and support material |  |  |  |  |  |  | resources Sysnet [21.4%]; Regenstrief Institute [21.4%] → Regenstrief Institute [21.4%]; Sysnet [21.4%] |
| 106 | Evaluation |  |  |  |  |  |  | resources Emmanuel Rugomboka [33.3%]; Wayne Naidoo [33.3%]; Rhonwyn Cornell [33.3%] → Rhonwyn Cornell [33.3%]; Emmanuel Rugomboka [33.3%]; Wayne Naidoo [33.3%] |
| 107 | **Provider Registry** |  |  |  | 43% → 45% |  |  |  |
| 114 | Review |  |  |  |  |  |  | resources Ryan Crichton [70%]; Intrahealth; Wayne Naidoo → Wayne Naidoo; Ryan Crichton [70%]; Intrahealth |
| 125 | Develop training and support plans |  | 2012-06-19 A |  | 40% → 100% | 0d → none |  |  |
| 132 | **OpenMRS** |  |  |  | 40% → 44% |  |  |  |
| 139 | Integration Testing |  |  |  |  |  |  | resources Desire Ruzigana [12.5%]; MoH OpenMRS team [12.5%] → MoH OpenMRS team [12.5%]; Desire Ruzigana [12.5%] |
| 142 | RHEA Team Testing and Iteration |  |  |  |  |  |  | resources Desire Ruzigana [16.7%]; Wayne Naidoo [16.7%]; Ryan Crichton [16.7%] → Wayne Naidoo [16.7%]; Desire Ruzigana [16.7%]; Ryan Crichton [16.7%] |
| 143 | MoH system approval |  |  |  |  |  |  | resources Emmanuel Rugomboka; Richard Gakuba → Richard Gakuba; Emmanuel Rugomboka |
| 145 | Develop training and support plan |  |  |  |  |  |  | resources Rhonwyn Cornell [4%]; Emmanuel Rugomboka [4%]; Michel Makolo [4%]; MoH OpenMRS team [4%]; Liz Peloso [4%] → Emmanuel Rugomboka [4%]; Rhonwyn Cornell [4%]; Liz Peloso [4%]; MoH OpenMRS team [4%]; Michel Makolo [4%] |
| 147 | **Deployment** |  |  |  | 5% → 9% |  |  |  |
| 148 | ANC clinic computers |  |  |  | 10% → 20% |  |  |  |
| 150 | **Training** |  |  |  | 6% → 13% |  |  |  |
| 151 | IT skills training |  |  |  | 10% → 20% |  |  |  |
| 152 | Application training |  |  |  |  |  |  | resources MoH OpenMRS team [41.7%]; Liz Peloso [41.7%] → Liz Peloso [41.7%]; MoH OpenMRS team [41.7%] |
| 153 | System support |  |  |  |  |  |  | resources Wayne Naidoo [13.3%]; MoH OpenMRS team [26.7%]; Desire Ruzigana [26.7%] → Desire Ruzigana [26.7%]; Wayne Naidoo [13.3%]; MoH OpenMRS team [26.7%] |
| 154 | Evaluation |  |  |  |  |  |  | resources Wayne Naidoo [16.7%]; Rhonwyn Cornell [16.7%]; Emmanuel Rugomboka [16.7%] → Emmanuel Rugomboka [16.7%]; Rhonwyn Cornell [16.7%]; Wayne Naidoo [16.7%] |
| 155 | **RapidSMS** | 2012-05-22 → 2012-08-06 (+76d) | 2012-05-22 → 2012-08-31 (+101d) | 1d? → 20d? |  | 149.43d → 0d |  |  |
| 157 | **Shared Health Record** |  | 2012-11-16 → 2012-09-26 (-51d) | 129d? → 91.5d? | 37% → 50% | 21.43d → 58.93d |  |  |
| 167 | Decide server requirements | 2012-05-22 A | 2012-05-22 A |  | 0% → 100% | 149.43d → none |  |  |
| 168 | Develop training and support plan |  |  |  | 30% → 90% | 81.43d → 10d |  | resources Wayne Naidoo [20%]; Rhonwyn Cornell [20%] → Rhonwyn Cornell [20%]; Wayne Naidoo [20%] |
| 169 | Develop training and support material |  | 2012-08-24 → 2012-08-03 (-21d) | 20d → 1w |  | 81.43d → 10d |  | resources Wayne Naidoo [25%]; Suranga Kasthurirathne [25%] → Wayne Naidoo; Suranga Kasthurirathne |
| 170 | Training | 2012-08-27 → 2012-08-20 (-7d) | 2012-08-31 → 2012-08-24 (-7d) | 5d → 1w |  | 76.43d → 0d | 164 → 169 | constraint none → must start on 2012-08-20; resources Suranga Kasthurirathne [50%]; Wayne Naidoo [50%] → Wayne Naidoo [50%]; Suranga Kasthurirathne [50%] |
| 171 | System support |  | 2012-11-16 → 2012-09-26 (-51d) | 3mo → 1.12mo |  | 21.43d → 58.93d |  | resources Wayne Naidoo [25%]; Suranga Kasthurirathne [25%] → Wayne Naidoo; Suranga Kasthurirathne |
| 173 | **Interoperability layer** |  |  |  | 29% → 31% |  |  |  |
| 183 | Technical Documentation Sprint |  | 2012-08-03 → 2012-07-30 (-4d) |  |  | 10d → 24d | 174 → none |  |
| 188 | Develop training and support plans |  | 2012-06-29 A |  | 40% → 100% | 0d → none |  |  |
| 190 | Training | 2012-08-20 → 2012-09-03 (+14d) | 2012-08-29 → 2012-09-07 (+9d) | 1.43w → 1w |  |  |  | constraint must start on 2012-08-20 → must start on 2012-09-03; resources Ryan Crichton [70%] → Ryan Crichton |
| 192 | Evaluation |  |  |  |  |  |  | resources Wayne Naidoo; Rhonwyn Cornell → Rhonwyn Cornell; Wayne Naidoo |

## Version 3 (saved 2012-08-07, file 120806 RHEA project plan 2010.mpp)

Last finish 2012-12-18 → 2013-01-14 (+27d). Complete tasks 40 → 44.

Added:

| ID | Task | Duration | Start | Finish | Predecessors | Constraint |
| --- | --- | --- | --- | --- | --- | --- |
| 143 | development of script for uploading Ubudehe data at health centres | 3w? | 2012-08-08 | 2012-08-28 |  | start no earlier than 2012-08-08 |
| 144 | integration of the appointment module | 2w? | 2012-08-01 A | 2012-08-14 |  | start no earlier than 2012-08-01 |
| 148 | Develop training material | 2w? | 2012-06-11 | 2012-06-25 | 147 |  |
| 153 | Deploy ANC OpenMRS module | 1mo | 2012-09-19 | 2012-10-16 | 152 | start no earlier than 2012-08-27 |

Changed:

| ID | Task | Start | Finish | Duration | Complete | Total float | Predecessors | Other |
| --- | --- | --- | --- | --- | --- | --- | --- | --- |
| 1 | **Project management** |  |  |  | 54% → 64% | 57.43d → 76.71d |  |  |
| 2 | Day to day project management |  |  |  | 55% → 70% | 70.43d → 89.71d |  | resources Rhonwyn Cornell; Carl Fourie [15%] → Carl Fourie [15%]; Rhonwyn Cornell |
| 3 | Day to day technical management |  |  |  | 55% → 70% | 70.43d → 89.71d |  |  |
| 5 | draft Apelon subcontract |  |  |  |  |  |  | resources Jonnea Smith [50%]; Carl Fourie; Rhonwyn Cornell [25%] → Rhonwyn Cornell [25%]; Jonnea Smith [50%]; Carl Fourie |
| 6 | Sign Apelon subcontract |  |  |  |  |  |  | resources Carl Fourie [1.7%]; Jonnea Smith [1.7%]; Chris Seebregts [1.7%] → Carl Fourie [1.7%]; Chris Seebregts [1.7%]; Jonnea Smith [1.7%] |
| 11 | Develop M&E plan |  |  |  |  | 135.43d → 154.71d |  | resources Rhonwyn Cornell [33.3%]; Wayne Naidoo [6.7%]; Emmanuel Rugomboka [20%]; Carl Fourie [6.7%] → Carl Fourie [6.7%]; Emmanuel Rugomboka [20%]; Wayne Naidoo [6.7%]; Rhonwyn Cornell [33.3%] |
| 13 | **Terminology Service** |  |  |  | 22% → 50% | 46.43d → 65.71d |  |  |
| 14 | **Technical Development** |  |  |  | 39% → 81% |  |  |  |
| 16 | Developer Integration Testing |  | 2012-06-01 A |  | 30% → 100% | 14.75d → none |  |  |
| 17 | Load Code Sets (LOINC-RW) | 2012-05-22 A |  |  | 0% → 60% |  |  |  |
| 18 | Develop Data Recovery and Backup Solution |  |  |  | 30% → 50% |  |  |  |
| 23 | Deploy in NDC |  |  |  |  |  |  | resources Ishimwe Ngezahayo [50%]; Hannes Venter [50%] → Hannes Venter [50%]; Ishimwe Ngezahayo [50%] |
| 24 | Documentation Sprint |  | 2012-06-15 A |  | 60% → 100% | 132.18d → none |  |  |
| 25 | Decide training and support plans |  | 2012-06-20 A |  | 90% → 100% | 0d → none |  |  |
| 26 | Training and support material developed | 2012-06-21 A | 2012-07-11 A |  | 0% → 100% | 113.43d → none |  |  |
| 27 | Training | 2012-07-23 A | 2012-07-26 → 2012-07-30 (+4d) | 4d → 1.12w | 0% → 88% | 31d → 29.4d |  | resources Apelon Inc; Hannes Venter → Hannes Venter; Apelon Inc |
| 28 | Apelon technical support |  |  |  | 10% → 20% | 46.43d → 65.71d |  |  |
| 29 | System evaluation |  |  |  |  |  |  | resources Wayne Naidoo; Rhonwyn Cornell → Rhonwyn Cornell; Wayne Naidoo |
| 30 | **Facility Registry** |  |  |  | 31% → 38% | 31.43d → 50.71d |  |  |
| 34 | Decide server requirements |  |  |  |  |  |  | resources InSTEDD [20%]; Michel Makolo [50%] → Michel Makolo [50%]; InSTEDD [20%] |
| 37 | Training and support materials developed |  |  |  | 60% → 70% | 114.43d → 133.71d |  |  |
| 38 | Pre-training prep |  | 2012-07-20 → 2012-08-10 (+21d) | 4w → 7w | 70% → 85% |  |  |  |
| 94 | Production configuration |  |  |  |  |  |  | resources Regenstrief Institute [50%]; Sysnet [50%] → Sysnet [50%]; Regenstrief Institute [50%] |
| 104 | Virtual training |  |  |  |  |  |  | resources Regenstrief Institute; Sysnet → Sysnet; Regenstrief Institute |
| 106 | Evaluation |  |  |  |  |  |  | resources Rhonwyn Cornell [33.3%]; Emmanuel Rugomboka [33.3%]; Wayne Naidoo [33.3%] → Rhonwyn Cornell [33.3%]; Wayne Naidoo [33.3%]; Emmanuel Rugomboka [33.3%] |
| 114 | Review |  |  |  |  |  |  | resources Wayne Naidoo; Ryan Crichton [70%]; Intrahealth → Ryan Crichton [70%]; Wayne Naidoo; Intrahealth |
| 130 | Evaluation |  |  |  |  |  |  | resources Rhonwyn Cornell [20%]; Wayne Naidoo [20%] → Wayne Naidoo [20%]; Rhonwyn Cornell [20%] |
| 132 | **OpenMRS** |  | 2012-10-18 → 2012-11-27 (+40d) | 108d? → 136d? | 44% → 53% | 42.43d → 33.71d |  |  |
| 133 | **Technical development** |  | 2012-09-13 → 2012-10-03 (+20d) | 82.5d → 97d? | 59% → 66% | 67.43d → 72.21d |  |  |
| 134 | Update OMRS Concept with Maternal Data Mappings |  | 2012-07-16 → 2012-08-13 (+28d) | 8w → 12w |  | 99.93d → 109.22d |  | was named Update OMRS Concept Dictionaries at MoH Sites with Maternal Data Mappings; resources MoH OpenMRS team [2.5%]; Desire Ruzigana [2.5%] → MoH OpenMRS team [1.7%]; Desire Ruzigana [1.7%] |
| 135 | Update HTML Form Implementations and Link them with Final Maternal Data Mappings |  | 2012-07-20 → 2012-08-21 (+32d) | 7w → 11w |  | 96.43d → 103.72d |  | resources Desire Ruzigana [2.9%]; Wayne Naidoo [2.9%] → Desire Ruzigana [1.8%]; Wayne Naidoo [1.8%] |
| 136 | Rwandan Primary Care and RHEA API Integration Design |  | 2012-07-30 → 2012-07-16 A (-14d) |  | 80% → 100% | 90.43d → none |  |  |
| 137 | Development - Rwandan Primary Care + RHEA API Integration |  | 2012-08-06 → 2012-09-03 (+28d) | 5w → 11w | 80% → 60% | 85.43d → 22d |  | resources Desire Ruzigana [20%] → Desire Ruzigana [9.1%] |
| 138 | Maternal Summary Development |  |  |  | 0% → 90% | 105.93d → 130.22d |  |  |
| 139 | Integration Testing |  | 2012-08-30 → 2012-10-03 (+34d) | 4w → 11w | 10% → 60% | 67.43d → -38d |  | resources MoH OpenMRS team [12.5%]; Desire Ruzigana [12.5%] → MoH OpenMRS team [4.5%]; Desire Ruzigana [4.5%] |
| 140 | Update Design Documentation | 2012-07-16 A |  |  | 0% → 20% | 105.93d → 125.21d |  |  |
| 141 | Develop User Documentation |  | 2012-08-28 → 2012-09-25 (+28d) |  |  | 79.43d → 78.21d |  |  |
| 142 | RHEA Team Testing and Iteration | 2012-08-30 → 2012-08-13 (-17d) | 2012-09-13 → 2012-08-24 (-20d) |  |  | 67.43d → -38d |  | constraint none → must start on 2012-08-13; resources Wayne Naidoo [16.7%]; Desire Ruzigana [16.7%]; Ryan Crichton [16.7%] → Ryan Crichton [16.7%]; Wayne Naidoo [16.7%]; Desire Ruzigana [16.7%] |
| 145 | MoH system approval | 2012-09-13 → 2012-10-04 (+21d) | 2012-09-13 → 2012-10-04 (+21d) |  |  | 67.43d → 72.21d |  | resources Richard Gakuba; Emmanuel Rugomboka → Emmanuel Rugomboka; Richard Gakuba |
| 147 | Develop training and support plan |  | 2012-06-18 → 2012-06-11 (-7d) | 2w → 1w |  | 130.43d → 144.71d |  | constraint none → start no earlier than 2012-07-25; resources Emmanuel Rugomboka [4%]; Rhonwyn Cornell [4%]; Liz Peloso [4%]; MoH OpenMRS team [4%]; Michel Makolo [4%] → Michel Makolo [8%]; Liz Peloso [8%]; Emmanuel Rugomboka [8%]; MoH OpenMRS team [8%]; Rhonwyn Cornell [8%] |
| 150 | **Deployment** |  | 2012-09-06 → 2012-10-16 (+40d) | 37d? → 65d? | 9% → 6% | 0d → 33.71d |  |  |
| 152 | Uploading of Ubhuthe database info on site | 2012-08-14 → 2012-08-29 (+15d) | 2012-09-06 → 2012-09-18 (+12d) | 3.6w? → 3w? |  | 0d → -17d | none → 143 | constraint must start on 2012-08-14 → none; resources MoH OpenMRS team [83.3%] → MoH OpenMRS team |
| 154 | **Training** |  | 2012-09-05 → 2012-09-28 (+23d) | 52d? → 69d? | 13% → 45% |  |  |  |
| 155 | IT skills training |  |  |  | 20% → 80% |  |  | resources Liz Peloso [21.9%]; MoH OpenMRS team [21.9%] → MoH OpenMRS team [21.9%]; Liz Peloso [21.9%] |
| 156 | Application training | 2012-08-13 → 2012-08-27 (+14d) | 2012-09-05 → 2012-09-28 (+23d) | 3.6w? → 5w |  | 0d → -17d | 155 → 152 | constraint must start on 2012-08-13 → must start on 2012-08-27; resources Liz Peloso [41.7%]; MoH OpenMRS team [41.7%] → MoH OpenMRS team [30%]; Liz Peloso [30%] |
| 157 | System support | 2012-09-07 → 2012-10-17 (+40d) | 2012-10-18 → 2012-11-27 (+40d) |  |  | 42.43d → 33.71d |  | resources Desire Ruzigana [26.7%]; Wayne Naidoo [13.3%]; MoH OpenMRS team [26.7%] → MoH OpenMRS team [26.7%]; Desire Ruzigana [26.7%]; Wayne Naidoo [13.3%] |
| 158 | Evaluation | 2012-09-10 → 2012-10-01 (+21d) | 2012-09-21 → 2012-10-12 (+21d) |  |  | 61.43d → 65.71d | none → 156 | resources Emmanuel Rugomboka [16.7%]; Rhonwyn Cornell [16.7%]; Wayne Naidoo [16.7%] → Rhonwyn Cornell [16.7%]; Emmanuel Rugomboka [16.7%]; Wayne Naidoo [16.7%] |
| 161 | **Shared Health Record** |  | 2012-09-26 → 2012-10-03 (+7d) | 91.5d? → 96.5d? |  | 58.93d → 73.21d |  |  |
| 162 | **Technical development** |  | 2012-08-27 → 2012-09-28 (+32d) | 70d → 94d | 65% → 67% | 80.43d → 75.71d |  |  |
| 164 | Developer Unit + Integtration Testing and Code Reviews |  | 2012-08-27 → 2012-08-06 (-21d) |  | 50% → 80% | 80.43d → 114.71d |  |  |
| 165 | Develop Load and Performance Testing Plan |  | 2012-07-20 A → 2012-07-20 |  | 100% → 80% | none → 39.6d |  |  |
| 166 | Develop Backup and Redudancy Strategy |  | 2012-07-27 A → 2012-07-27 |  | 100% → 80% | none → 35d |  |  |
| 167 | Load and Performance Testing | 2012-07-30 A → 2012-09-17 (+49d) | 2012-08-10 A → 2012-09-28 (+49d) |  | 100% → 0% | none → 0d |  | constraint none → must start on 2012-09-17 |
| 168 | RHEA Team System Testing + Iteration | 2012-08-13 → 2012-08-20 (+7d) | 2012-08-24 → 2012-08-31 (+7d) |  |  | 58.93d → 0d | 167 → none | constraint none → must start on 2012-08-20 |
| 169 | MoH system approval | 2012-08-27 → 2012-09-03 (+7d) | 2012-08-28 → 2012-09-04 (+7d) |  |  | 79.43d → 93.71d |  |  |
| 170 | Deployment | 2012-08-27 → 2012-09-03 (+7d) | 2012-08-31 → 2012-09-07 (+7d) |  |  | 76.43d → 90.71d |  |  |
| 172 | Develop training and support plan |  |  |  | 90% → 10% |  |  | resources Rhonwyn Cornell [20%]; Wayne Naidoo [20%] → Wayne Naidoo [20%]; Rhonwyn Cornell [20%] |
| 173 | Develop training and support material | 2012-07-27 → 2012-07-30 (+3d) |  |  |  |  |  |  |
| 174 | Training |  |  |  |  |  |  | resources Wayne Naidoo [50%]; Suranga Kasthurirathne [50%] → Suranga Kasthurirathne [50%]; Wayne Naidoo [50%] |
| 175 | System support | 2012-08-27 → 2012-09-03 (+7d) | 2012-09-26 → 2012-10-03 (+7d) |  |  | 58.93d → 73.21d |  | resources Wayne Naidoo; Suranga Kasthurirathne → Suranga Kasthurirathne; Wayne Naidoo |
| 177 | **Interoperability layer** |  | 2012-12-18 → 2013-01-14 (+27d) | 150.43d → 169.71d | 31% → 33% |  |  |  |
| 178 | **Technical development** |  |  |  | 69% → 81% |  |  |  |
| 183 | Develop Transaction Edit page |  | 2012-06-25 A |  | 70% → 100% | 26d → none |  |  |
| 184 | Develop Audit Log functionality |  | 2012-07-02 A |  | 70% → 100% | 21d → none |  |  |
| 185 | System Testing and bug fixes |  |  |  | 40% → 55% |  |  |  |
| 186 | User Documentation Sprint | 2012-08-01 A |  |  | 0% → 20% |  |  |  |
| 187 | Technical Documentation Sprint |  |  |  | 70% → 60% |  |  |  |
| 188 | Implement Orchestrations for developed components |  | 2012-08-02 → 2012-09-14 (+43d) | 2w → 2.2mo | 80% → 40% | 6d → 0d |  | constraint none → must finish on 2012-09-14; resources Ryan Crichton [15%] → Ryan Crichton [3.4%] |
| 190 | Deploy system | 2012-08-13 → 2012-09-17 (+35d) | 2012-08-20 → 2012-09-24 (+35d) |  |  | 0d → 77.5d |  | constraint must start on 2012-08-13 → none |
| 195 | System support | 2012-08-20 → 2012-09-17 (+28d) | 2012-12-18 → 2013-01-14 (+27d) |  |  |  | 190 → 188 |  |

| ID | Task | Start | Finish | Total float | Other |
| --- | --- | --- | --- | --- | --- |
| 196 | Evaluation | 2012-09-17 → 2012-09-24 (+7d) | 2012-09-19 → 2012-09-27 (+8d) | 0d → 77.5d | constraint must start on 2012-09-17 → none; resources Rhonwyn Cornell; Wayne Naidoo → Wayne Naidoo; Rhonwyn Cornell |

## Version 4 (saved 2012-08-08, file 120808 RHEA project plan 2010.mpp)

Last finish stays 2013-01-14.

Changed:

| ID | Task | Start | Finish | Duration | Complete | Total float | Predecessors | Other |
| --- | --- | --- | --- | --- | --- | --- | --- | --- |
| 2 | Day to day project management |  |  |  |  |  |  | resources Carl Fourie [15%]; Rhonwyn Cornell → Rhonwyn Cornell; Carl Fourie [15%] |
| 3 | Day to day technical management |  |  |  |  |  |  | resources Carl Fourie [15%]; Wayne Naidoo → Wayne Naidoo; Carl Fourie [15%] |
| 4 | submit Apelon subcontract approval to CARDNO |  |  |  |  |  |  | resources Jonnea Smith [50%]; Carl Fourie → Carl Fourie; Jonnea Smith [50%] |
| 5 | draft Apelon subcontract |  |  |  |  |  |  | resources Rhonwyn Cornell [25%]; Jonnea Smith [50%]; Carl Fourie → Jonnea Smith [50%]; Rhonwyn Cornell [25%]; Carl Fourie |
| 6 | Sign Apelon subcontract |  |  |  |  |  |  | resources Carl Fourie [1.7%]; Chris Seebregts [1.7%]; Jonnea Smith [1.7%] → Carl Fourie [1.7%]; Jonnea Smith [1.7%]; Chris Seebregts [1.7%] |
| 23 | Deploy in NDC |  |  |  |  |  |  | resources Hannes Venter [50%]; Ishimwe Ngezahayo [50%] → Ishimwe Ngezahayo [50%]; Hannes Venter [50%] |
| 25 | Decide training and support plans |  |  |  |  |  |  | resources Rhonwyn Cornell [2%]; Apelon Inc [4%] → Apelon Inc [4%]; Rhonwyn Cornell [2%] |
| 26 | Training and support material developed |  |  |  |  |  |  | resources Hannes Venter [5%]; Apelon Inc [15%] → Apelon Inc [15%]; Hannes Venter [5%] |
| 27 | Training |  |  |  |  |  |  | resources Hannes Venter; Apelon Inc → Apelon Inc; Hannes Venter |
| 35 | Support structure designed |  |  |  |  |  |  | resources Rhonwyn Cornell [20%]; InSTEDD [20%] → InSTEDD [20%]; Rhonwyn Cornell [20%] |
| 42 | Evaluation |  |  |  |  |  |  | resources Wayne Naidoo [20%]; Rhonwyn Cornell [20%] → Rhonwyn Cornell [20%]; Wayne Naidoo [20%] |
| 94 | Production configuration |  |  |  |  |  |  | resources Sysnet [50%]; Regenstrief Institute [50%] → Regenstrief Institute [50%]; Sysnet [50%] |
| 95 | Load data from Ubedehe |  |  |  |  |  |  | resources Sysnet [50%]; Regenstrief Institute [50%] → Regenstrief Institute [50%]; Sysnet [50%] |
| 102 | Define support requirements |  |  |  |  |  |  | resources Michel Makolo; Regenstrief Institute → Regenstrief Institute; Michel Makolo |
| 103 | Develop training and support material |  |  |  |  |  |  | resources Regenstrief Institute [21.4%]; Sysnet [21.4%] → Sysnet [21.4%]; Regenstrief Institute [21.4%] |
| 104 | Virtual training |  |  |  |  |  |  | resources Sysnet; Regenstrief Institute → Regenstrief Institute; Sysnet |
| 106 | Evaluation |  |  |  |  |  |  | resources Rhonwyn Cornell [33.3%]; Wayne Naidoo [33.3%]; Emmanuel Rugomboka [33.3%] → Wayne Naidoo [33.3%]; Rhonwyn Cornell [33.3%]; Emmanuel Rugomboka [33.3%] |
| 114 | Review |  |  |  |  |  |  | resources Ryan Crichton [70%]; Wayne Naidoo; Intrahealth → Wayne Naidoo; Intrahealth; Ryan Crichton [70%] |
| 128 | Schedule training |  |  |  |  |  |  | resources Rhonwyn Cornell [30%]; Intrahealth [30%] → Intrahealth [30%]; Rhonwyn Cornell [30%] |
| 132 | **OpenMRS** |  | 2012-11-27 → 2012-10-05 (-53d) | 136d? → 99d? | 53% → 54% | 33.71d → 70.71d |  |  |
| 133 | **Technical development** |  |  |  | 66% → 67% |  |  |  |
| 142 | RHEA Team Testing and Iteration |  |  |  |  |  |  | resources Ryan Crichton [16.7%]; Wayne Naidoo [16.7%]; Desire Ruzigana [16.7%] → Desire Ruzigana [16.7%]; Ryan Crichton [16.7%]; Wayne Naidoo [16.7%] |
| 143 | development of script for uploading Ubudehe data at health centres |  | 2012-08-28 → 2012-08-21 (-7d) | 3w? → 2w? |  | -17d → 88.71d |  |  |
| 147 | Develop training and support plan |  |  |  |  |  |  | resources Michel Makolo [8%]; Liz Peloso [8%]; Emmanuel Rugomboka [8%]; MoH OpenMRS team [8%]; Rhonwyn Cornell [8%] → Liz Peloso [8%]; Emmanuel Rugomboka [8%]; Rhonwyn Cornell [8%]; Michel Makolo [8%]; MoH OpenMRS team [8%] |
| 150 | **Deployment** |  | 2012-10-16 → 2012-09-21 (-25d) | 65d? → 48d? |  | 33.71d → 80.71d |  |  |
| 152 | Uploading of Ubhuthe database info on site | 2012-08-29 → 2012-08-22 (-7d) | 2012-09-18 → 2012-09-11 (-7d) |  |  | -17d → 88.71d |  |  |
| 153 | Deploy ANC OpenMRS module | 2012-09-19 → 2012-08-27 (-23d) | 2012-10-16 → 2012-09-21 (-25d) |  |  | 33.71d → 80.71d | 152 → none |  |
| 154 | **Training** |  | 2012-09-28 → 2012-09-20 (-8d) | 69d? → 63d? | 45% → 50% |  |  |  |
| 156 | Application training |  | 2012-09-28 → 2012-09-20 (-8d) | 5w → 3.8w |  | -17d → 0d | 152 → none | resources MoH OpenMRS team [30%]; Liz Peloso [30%] → MoH OpenMRS team [39.5%]; Liz Peloso [39.5%] |
| 157 | System support | 2012-10-17 → 2012-08-27 (-51d) | 2012-11-27 → 2012-10-05 (-53d) |  |  | 33.71d → 0d | 150 → none | constraint none → must start on 2012-08-27; resources MoH OpenMRS team [26.7%]; Desire Ruzigana [26.7%]; Wayne Naidoo [13.3%] → Wayne Naidoo [13.3%]; Desire Ruzigana [26.7%]; MoH OpenMRS team [26.7%] |
| 158 | Evaluation | 2012-10-01 → 2012-09-21 (-10d) | 2012-10-12 → 2012-10-04 (-8d) |  |  | 65.71d → 71.71d |  |  |
| 173 | Develop training and support material |  |  |  |  |  |  | resources Wayne Naidoo; Suranga Kasthurirathne → Suranga Kasthurirathne; Wayne Naidoo |
| 174 | Training |  |  |  |  |  |  | resources Suranga Kasthurirathne [50%]; Wayne Naidoo [50%] → Wayne Naidoo [50%]; Suranga Kasthurirathne [50%] |
